# Network_WBS

Schedule from MS Project, 2014-09-08 to 2015-09-28, costs in $.
Microsoft

## Calendars

- Standard: Mon-Fri 08:00-12:00, 13:00-17:00; Sat-Sun off.

## Resources

| Resource | Rate |
| --- | --- |
| Project Manager 1 | 52 |
| Project Manager 2 | 47 |
| Network Team Lead | 45 |
| Network Engineer | 50 |
| Network Engineer | 41 |
| Windows System Admin 1 | 39 |
| Windows System Admin 2 | 37.5 |
| Network Architect | 55 |
| Wireless Network Admin 1 | 44.85 |
| Technical Writer | 38.92 |
| Technical Writer 2 | 38.92 |
| Budget Analyst 1 | 35 |
| Electrician 1 | 50.08 |
| Network Wiring Team | 187.5 |
| System Test Analyst 1 | 34.85 |
| System Test Analyst 2 | 31.25 |
| Documentation Analyst 1 | 21.3 |
| Risk Analyst 1 | 33 |
| Ethernet Cabling | 6 |
| Fiber Optic Cables | 149 |
| HP Servers | 6300 |
| Wireless Access Points | 3100 |
| SANS Storage | 15700 |
| Trainer | 24.5 |
| Training Manager | 27.85 |
| Construction worker 1 | 19.9 |
| Construction worker 2 | 24 |
| Workstation/Computer | 934 |
| Monitors | 475 |
| Tools | 50 |
| Desks | 289 |
| Equipment Rack | 1150 |
| Patch Panel | 30.55 |
| Internet Router | 8700 |
| LAN Switch | 4200 |
| Ethernet Connectors | 1 |
| Procurement Officer | 32 |
| Keyboard | 75 |
| Mice | 25 |
| Application Software | 99 |
| Operating System | 129 |
| Phone | 430 |
| Power Strips | 25 |
| Power Cables | 20 |
| Uninterruptable Power Supply | 320 |
| General Manager | 101 |
| Firewall | 12500 |
| Intrusion Detection System | 9600 |
| Scanner | 399 |
| Check Printer | 1125 |
| MICR Toner | 446 |
| Check stock | 64 |
| Scanner Toner | 367.99 |
| Accountant | 33.65 |
| Accounts Payable Lead | 16.82 |
| Accounts Receivable Coordinator | 19.23 |
| Security Administrator | 31.25 |
| System/Process Remediation Manager | 28.84 |
| Remediation Lead | 16.82 |
| UAT Lead | 21.63 |
| Document Automation Manager | 65 |
| Office Manager | 31.25 |

## Schedule

| ID | WBS | Task | Duration | Start | Finish | Predecessors | Total slack | Resources | Work | Cost |
| --- | --- | --- | --- | --- | --- | --- | --- | --- | --- | --- |
| 1 | 1 | **Designing Information Technology Solution** | 276d? | 2014-09-08 | 2015-09-28 |  | 0d |  | 4110h | 190,754.52 |
| 2 | 1.1 | **Initiate** | 13d | 2014-09-08 | 2014-09-24 |  | 0d |  | 408h | 21,412.16 |
| 3 | 1.1.1 | **Identify Team Members** | 4d | 2014-09-08 | 2014-09-11 |  | 0d |  | 176h | 9,652.16 |
| 4 | 1.1.1.1 | Kick-off Meeting | 1d | 2014-09-08 | 2014-09-08 |  | 0d | Budget Analyst 1; General Manager; Network Architect; Network Engineer; Network Team Lead; Network Wiring Team; Procurement Officer; Project Manager 1; Project Manager 2; Risk Analyst 1; System Test Analyst 1; System Test Analyst 2; Technical Writer | 104h | 5,940.16 |
| 5 | 1.1.1.2 | Meet with Customer and Key Stakeholders | 1d | 2014-09-09 | 2014-09-09 | 4 | 0d | General Manager; Project Manager 1; Project Manager 2 | 24h | 1,600 |
| 6 | 1.1.1.3 | Conduct Baseline Assessment | 2d | 2014-09-10 | 2014-09-11 | 5 | 0d | Project Manager 1; Project Manager 2; Risk Analyst 1 | 48h | 2,112 |
| 7 | 1.1.2 | **Develop Project Requirements** | 3d | 2014-09-12 | 2014-09-16 |  | 0d |  | 56h | 3,184 |
| 8 | 1.1.2.1 | Establish Sytem Operational Baseline | 1d | 2014-09-12 | 2014-09-12 | 6 | 0d | General Manager; Project Manager 1; Project Manager 2 | 24h | 1,600 |
| 9 | 1.1.2.2 | Develop Project Scope | 2d | 2014-09-15 | 2014-09-16 | 8 | 0d | Project Manager 1; Project Manager 2 | 32h | 1,584 |
| 10 | 1.1.3 | **Budget Planning** | 6d | 2014-09-17 | 2014-09-24 |  | 0d |  | 176h | 8,576 |
| 11 | 1.1.3.1 | Establish Hardware Budget | 2d | 2014-09-17 | 2014-09-18 | 9 | 0d | Budget Analyst 1; Project Manager 1; Project Manager 2 | 48h | 2,144 |
| 12 | 1.1.3.2 | Establish Software Budget | 2d | 2014-09-19 | 2014-09-22 | 11 | 0d | Budget Analyst 1; Project Manager 1; Project Manager 2 | 48h | 2,144 |
| 13 | 1.1.3.3 | Establish Personnel Budget | 2d | 2014-09-23 | 2014-09-24 | 12 | 0d | Budget Analyst 1; General Manager; Project Manager 1; Project Manager 2; Risk Analyst 1 | 80h | 4,288 |
| 14 | 1.2 | **Plan** | 6d | 2014-09-25 | 2014-10-02 |  | 0d |  | 120h | 6,013.44 |
| 15 | 1.2.1 | **Develop Documentation** | 6d | 2014-09-25 | 2014-10-02 |  | 0d |  | 120h | 6,013.44 |
| 16 | 1.2.1.1 | Create Project Schedule | 1d | 2014-09-25 | 2014-09-25 | 13 | 0d | Project Manager 1; Project Manager 2 | 16h | 792 |
| 17 | 1.2.1.2 | Create Project Charter | 2d | 2014-09-26 | 2014-09-29 | 16 | 0d | Project Manager 1; Project Manager 2; Technical Writer; Technical Writer 2 | 64h | 2,829.44 |
| 18 | 1.2.1.3 | Create WBS | 2d | 2014-09-30 | 2014-10-01 | 17 | 0d | Project Manager 1; Project Manager 2 | 32h | 1,584 |
| 19 | 1.2.1.4 | Obtain Approvals | 1d | 2014-10-02 | 2014-10-02 | 18 | 0d | General Manager | 8h | 808 |
| 20 | 1.3 | **Design** | 30d? | 2014-10-03 | 2014-11-13 |  | 0d |  | 686h | 35,556.84 |
| 21 | 1.3.1 | **Create Design Documentation** | 4d | 2014-10-03 | 2014-10-08 |  | 0d |  | 76h | 4,066.8 |
| 22 | 1.3.1.1 | Develop Technical Requirements | 2d | 2014-10-03 | 2014-10-06 | 19 | 0d | Network Architect; Technical Writer; Technical Writer 2 | 48h | 2,125.44 |
| 23 | 1.3.1.2 | Create System Architecture Design | 1d | 2014-10-07 | 2014-10-07 | 22 | 0d | Network Architect; Technical Writer | 16h | 751.36 |
| 24 | 1.3.1.3 | Create Wiring Design | 1d | 2014-10-08 | 2014-10-08 | 23 | 0d | Network Architect; Network Wiring Team [50%] | 12h | 1,190 |

| ID | WBS | Task | Duration | Start | Finish | Predecessors | Total slack | Resources | Work | Cost |
| --- | --- | --- | --- | --- | --- | --- | --- | --- | --- | --- |
| 25 | 1.3.2 | **Physical Design** | 26d? | 2014-10-09 | 2014-11-13 |  | 0d |  | 610h | 31,490.04 |
| 26 | 1.3.2.1 | **Determine Server Room Location** | 4d | 2014-10-09 | 2014-10-14 |  | 0d |  | 74h | 3,838.04 |
| 27 | 1.3.2.1.1 | Identify Data Closet | 1d | 2014-10-09 | 2014-10-09 | 24 | 0d | Network Wiring Team [25%]; Network Architect; Project Manager 1 | 18h | 1,231 |
| 28 | 1.3.2.1.2 | Identify Environmental Requirement | 1d | 2014-10-10 | 2014-10-10 | 27 | 0d | Project Manager 1; Construction worker 1 [50%]; Construction worker 2 [50%] | 16h | 591.6 |
| 29 | 1.3.2.1.3 | Identify Electrical Requirement | 1d | 2014-10-13 | 2014-10-13 | 28 | 0d | Project Manager 1; Electrician 1 | 16h | 816.64 |
| 30 | 1.3.2.1.4 | Determine Wireless Access Point Locations | 1d | 2014-10-14 | 2014-10-14 | 29 | 0d | Network Architect; Network Engineer; Wireless Network Admin 1 | 24h | 1,198.8 |
| 31 | 1.3.2.2 | **Assess Suppliers** | 22d? | 2014-10-15 | 2014-11-13 |  | 0d |  | 536h | 27,652 |
| 32 | 1.3.2.2.1 | **Hardware Requirements** | 9d | 2014-10-15 | 2014-10-27 |  | 0d |  | 176h | 11,088 |
| 33 | 1.3.2.2.1.1 | **Identify Hardware Components** | 8d | 2014-10-15 | 2014-10-24 |  | 0d |  | 136h | 9,340 |
| 34 | 1.3.2.2.1.1.1 | Design Workstation Specifications | 2d | 2014-10-15 | 2014-10-16 | 30 | 0d | Windows System Admin 1; Windows System Admin 2; Project Manager 1 | 48h | 2,056 |
| 35 | 1.3.2.2.1.1.2 | Design Server hardware Specifications | 2d | 2014-10-17 | 2014-10-20 | 34 | 0d | Windows System Admin 1; Windows System Admin 2 | 32h | 1,224 |
| 36 | 1.3.2.2.1.1.3 | Identify Layer 2 Devices (Switching/Data Closets) | 1d | 2014-10-21 | 2014-10-21 | 35 | 0d | Network Architect; Network Engineer | 16h | 840 |
| 37 | 1.3.2.2.1.1.4 | Identify Layer 3 Devices (Internet/WAN) | 1d | 2014-10-22 | 2014-10-22 | 36 | 0d | Network Architect; Network Engineer | 16h | 840 |
| 38 | 1.3.2.2.1.1.5 | Identify Wireless Devices | 1d | 2014-10-23 | 2014-10-23 | 37 | 0d | Network Architect; Wireless Access Points | 8h | 3,540 |
| 39 | 1.3.2.2.1.1.6 | Identify Firewall/Intrusion Detection System | 1d | 2014-10-24 | 2014-10-24 | 38 | 0d | Network Architect; Network Engineer | 16h | 840 |
| 40 | 1.3.2.2.1.2 | Select Hardware Components | 1d | 2014-10-27 | 2014-10-27 | 39 | 0d | Network Architect; Project Manager 1; Budget Analyst 1; Windows System Admin 1; Windows System Admin 2 | 40h | 1,748 |
| 41 | 1.3.2.2.2 | **Software Requirements** | 5d | 2014-10-28 | 2014-11-03 |  | 0d |  | 176h | 7,868 |
| 42 | 1.3.2.2.2.1 | **Identify Software Components** | 4d | 2014-10-28 | 2014-10-31 |  | 0d |  | 136h | 6,184 |
| 43 | 1.3.2.2.2.1.1 | Identify Server OS | 2d | 2014-10-28 | 2014-10-29 | 40 | 0d | Project Manager 1; Network Architect; Windows System Admin 1; Windows System Admin 2 | 64h | 2,936 |
| 44 | 1.3.2.2.2.1.2 | Identify Workstation OS | 1d | 2014-10-30 | 2014-10-30 | 43 | 0d | Project Manager 1; Project Manager 2; Windows System Admin 1; Windows System Admin 2 | 32h | 1,404 |
| 45 | 1.3.2.2.2.1.3 | Identify Other Application Specific Software | 1d | 2014-10-31 | 2014-10-31 | 44 | 0d | Project Manager 1; Project Manager 2; Windows System Admin 1; Windows System Admin 2; Network Architect | 40h | 1,844 |
| 46 | 1.3.2.2.2.2 | Select Software | 1d | 2014-11-03 | 2014-11-03 | 45 | 0d | Project Manager 1; Project Manager 2; Budget Analyst 1; Windows System Admin 1; Windows System Admin 2 | 40h | 1,684 |
| 47 | 1.3.2.2.3 | **Subcontractor Requirements** | 8d? | 2014-11-04 | 2014-11-13 |  | 0d |  | 184h | 8,696 |
| 48 | 1.3.2.2.3.1 | **Identify Required Services** | 2d | 2014-11-04 | 2014-11-05 |  | 0d |  | 56h | 2,768 |
| 49 | 1.3.2.2.3.1.1 | Identify Internet Provider | 1d | 2014-11-04 | 2014-11-04 | 46 | 0d | Project Manager 1; Project Manager 2; Network Architect; Network Engineer | 32h | 1,632 |
| 50 | 1.3.2.2.3.1.2 | Identify Internal Wiring Contractor (Fiber/Ethernet) | 1d | 2014-11-05 | 2014-11-05 | 49 | 0d | Project Manager 1; Network Architect; Budget Analyst 1 | 24h | 1,136 |

| ID | WBS | Task | Duration | Start | Finish | Predecessors | Total slack | Resources | Work | Cost |
| --- | --- | --- | --- | --- | --- | --- | --- | --- | --- | --- |
| 51 | 1.3.2.2.3.2 | **Select Services and Providers** | 3d | 2014-11-06 | 2014-11-10 |  | 0d |  | 72h | 3,768 |
| 52 | 1.3.2.2.3.2.1 | Develop SLA Agreement | 3d | 2014-11-06 | 2014-11-10 | 50 | 0d | Project Manager 1; Network Architect; Network Engineer | 72h | 3,768 |
| 53 | 1.3.2.2.3.3 | Issue Purchase Orders | 2d | 2014-11-11 | 2014-11-12 | 52 | 0d | Budget Analyst 1; Procurement Officer; Project Manager 1 | 48h | 1,904 |
| 54 | 1.3.2.2.3.4 | Order Equipment and Services | 1d? | 2014-11-13 | 2014-11-13 | 53 | 0d | Procurement Officer | 8h | 256 |
| 55 | 1.4 | **Execute** | 15d? | 2014-11-14 | 2014-12-04 |  | 0d |  | 248h | 22,415.6 |
| 56 | 1.4.1 | **Internet** | 4d? | 2014-11-14 | 2014-11-19 |  | 0d |  | 80h | 12,335.2 |
| 57 | 1.4.1.1 | Organize appointment with Internet provider | 1d? | 2014-11-14 | 2014-11-14 | 54 | 0d | Project Manager 1; Network Architect; Network Engineer | 24h | 1,256 |
| 58 | 1.4.1.2 | Install Internet | 2d | 2014-11-17 | 2014-11-18 | 57 | 0d | Network Architect; Network Engineer; Internet Router | 32h | 10,380 |
| 59 | 1.4.1.3 | Test connectivity | 1d | 2014-11-19 | 2014-11-19 | 58 | 0d | System Test Analyst 1; System Test Analyst 2; Documentation Analyst 1 | 24h | 699.2 |
| 60 | 1.4.2 | **Network Cabling** | 4d | 2014-11-20 | 2014-11-25 |  | 0d |  | 56h | 4,777.6 |
| 61 | 1.4.2.1 | Install network cabling | 1d | 2014-11-20 | 2014-11-20 | 59 | 0d | Network Wiring Team | 8h | 1,500 |
| 62 | 1.4.2.2 | Test ports | 1d | 2014-11-21 | 2014-11-21 | 61 | 0d | Network Wiring Team | 8h | 1,500 |
| 63 | 1.4.2.3 | Install Wireless Access Points | 1d | 2014-11-24 | 2014-11-24 | 62 | 0d | Wireless Network Admin 1; Network Architect; Network Engineer | 24h | 1,198.8 |
| 64 | 1.4.2.4 | Test connectivity | 1d | 2014-11-25 | 2014-11-25 | 63 | 0d | System Test Analyst 1; Windows System Admin 2 | 16h | 578.8 |
| 65 | 1.4.3 | **Hardware and Software** | 7d | 2014-11-26 | 2014-12-04 |  | 0d |  | 112h | 5,302.8 |
| 66 | 1.4.3.1 | **Configure desktops** | 7d | 2014-11-26 | 2014-12-04 |  | 0d |  | 112h | 5,302.8 |
| 67 | 1.4.3.1.1 | Interface patient, supplier, billing and payment profiles. | 2d | 2014-11-26 | 2014-11-27 | 64 | 0d | Windows System Admin 1; Windows System Admin 2 | 32h | 1,224 |
| 68 | 1.4.3.1.2 | Conduct User tests in production | 2d | 2014-11-28 | 2014-12-01 | 67 | 0d | Windows System Admin 1; System Test Analyst 1 | 32h | 1,181.6 |
| 69 | 1.4.3.1.3 | Review and Update System Reporting | 1d | 2014-12-02 | 2014-12-02 | 68 | 0d | System Test Analyst 1; Documentation Analyst 1 | 16h | 449.2 |
| 70 | 1.4.3.1.4 | Obtain final approval | 2d | 2014-12-03 | 2014-12-04 | 69 | 0d | Project Manager 1; General Manager | 32h | 2,448 |
| 71 | 1.5 | **Test** | 19d | 2014-12-05 | 2014-12-31 |  | 0d |  | 296h | 11,009.6 |
| 72 | 1.5.1 | **Conduct Initial Testing** | 19d | 2014-12-05 | 2014-12-31 |  | 0d |  | 296h | 11,009.6 |
| 73 | 1.5.1.1 | **Conduct multiple hardware and software test** | 19d | 2014-12-05 | 2014-12-31 |  | 0d |  | 296h | 11,009.6 |
| 74 | 1.5.1.1.1 | Demo System to Stakeholders | 1d | 2014-12-05 | 2014-12-05 | 70 | 0d | Network Architect; Project Manager 1; General Manager | 24h | 1,664 |

| ID | WBS | Task | Duration | Start | Finish | Predecessors | Total slack | Resources | Work | Cost |
| --- | --- | --- | --- | --- | --- | --- | --- | --- | --- | --- |
| 75 | 1.5.1.1.2 | **Conduct UAT** | 2d | 2014-12-08 | 2014-12-09 |  | 0d |  | 32h | 1,057.6 |
| 76 | 1.5.1.1.2.1 | Correct test scripts | 1d | 2014-12-08 | 2014-12-08 | 74 | 0d | System Test Analyst 1; System Test Analyst 2 | 16h | 528.8 |
| 77 | 1.5.1.1.2.2 | Restest corrected scripts | 1d | 2014-12-09 | 2014-12-09 | 76 | 0d | System Test Analyst 1; System Test Analyst 2 | 16h | 528.8 |
| 78 | 1.5.1.1.3 | **Harden/Refine System Hardware & Software** | 3d | 2014-12-10 | 2014-12-12 |  | 0d |  | 48h | 2,281.6 |
| 79 | 1.5.1.1.3.1 | Retest system | 2d | 2014-12-10 | 2014-12-11 | 77 | 0d | System Test Analyst 1; System Test Analyst 2 | 32h | 1,057.6 |
| 80 | 1.5.1.1.3.2 | Obtain pre-approval of system | 1d | 2014-12-12 | 2014-12-12 | 79 | 0d | Project Manager 1; General Manager | 16h | 1,224 |
| 81 | 1.5.1.1.4 | **Conduct training sessions** | 13d | 2014-12-15 | 2014-12-31 |  | 0d |  | 192h | 6,006.4 |
| 82 | 1.5.1.1.4.1 | Finalize training documents | 2d | 2014-12-15 | 2014-12-16 | 80 | 0d | Training Manager | 16h | 445.6 |
| 83 | 1.5.1.1.4.2 | **Schedule sessions** | 11d | 2014-12-17 | 2014-12-31 |  | 0d | Training Manager | 176h | 5,560.8 |
| 84 | 1.5.1.1.4.2.1 | Train all staff | 3d | 2014-12-17 | 2014-12-19 | 82 | 0d | Trainer | 24h | 588 |
| 85 | 1.5.1.1.4.2.2 | Allow Customer preliminary testing period | 5d | 2014-12-22 | 2014-12-26 | 84 | 0d | System Test Analyst 1 | 40h | 1,394 |
| 86 | 1.5.1.1.4.2.3 | Address System Testing Feedback from Customer | 3d | 2014-12-29 | 2014-12-31 | 85 | 0d | Project Manager 2 | 24h | 1,128 |
| 87 | 1.6 | **Deploy** | 7d | 2015-01-01 | 2015-01-09 |  | 0d |  | 56h | 1,938.8 |
| 88 | 1.6.1 | Rollout new platform | 1d | 2015-01-01 | 2015-01-01 | 86 | 0d | Training Manager | 8h | 222.8 |
| 89 | 1.6.2 | Facilitate migration | 3d | 2015-01-02 | 2015-01-06 | 88 | 0d | Project Manager 2 | 24h | 1,128 |
| 90 | 1.6.3 | Conduct further customer training | 3d | 2015-01-07 | 2015-01-09 | 89 | 0d | Trainer | 24h | 588 |
| 91 | 1.7 | **Control** | 170d | 2015-01-12 | 2015-09-04 |  | 0d |  | 2056h | 79,268.4 |
| 92 | 1.7.1 | Scope verification and control | 5d | 2015-01-12 | 2015-01-16 | 90 | 0d | System Test Analyst 1 | 40h | 1,394 |
| 93 | 1.7.2 | Manage schedule/control | 20d | 2015-01-19 | 2015-02-13 | 92 | 0d | System Test Analyst 1; System Test Analyst 2 | 320h | 10,576 |
| 94 | 1.7.3 | Monitor cost control | 40d | 2015-02-16 | 2015-04-10 | 93 | 0d | Budget Analyst 1 | 320h | 11,200 |
| 95 | 1.7.4 | Conduct quality control | 20d | 2015-04-13 | 2015-05-08 | 94 | 0d | System Test Analyst 1; System Test Analyst 2 | 320h | 10,576 |
| 96 | 1.7.5 | Administer performance reporting | 14d | 2015-05-11 | 2015-05-28 | 95 | 0d | System Test Analyst 1; System Test Analyst 2 | 224h | 7,403.2 |
| 97 | 1.7.6 | Conduct risk control | 5d | 2015-05-29 | 2015-06-04 | 96 | 0d | Risk Analyst 1 | 40h | 1,320 |
| 98 | 1.7.7 | Contract administration | 45d | 2015-06-05 | 2015-08-06 | 97 | 0d | Project Manager 2 | 360h | 16,920 |

| ID | WBS | Task | Duration | Start | Finish | Predecessors | Total slack | Resources | Work | Cost |
| --- | --- | --- | --- | --- | --- | --- | --- | --- | --- | --- |
| 99 | 1.7.8 | **Handover** | 21d | 2015-08-07 | 2015-09-04 |  | 0d |  | 432h | 19,879.2 |
| 100 | 1.7.8.1 | Meet with customer and key Stakeholders | 2d | 2015-08-07 | 2015-08-10 | 98 | 0d | General Manager; Project Manager 2; Procurement Officer | 48h | 2,880 |
| 101 | 1.7.8.2 | Deliver project documentation to client | 1d | 2015-08-11 | 2015-08-11 | 100 | 0d | General Manager; Network Team Lead | 16h | 1,168 |
| 102 | 1.7.8.3 | Conduct post project review and evaluation | 3d | 2015-08-12 | 2015-08-14 | 101 | 0d | Documentation Analyst 1; General Manager; Training Manager | 72h | 3,603.6 |
| 103 | 1.7.8.4 | Review and deliver operating and maintenance instructions | 3d | 2015-08-17 | 2015-08-19 | 102 | 0d | General Manager; Training Manager | 48h | 3,092.4 |
| 104 | 1.7.8.5 | Provide support for implementation | 5d | 2015-08-20 | 2015-08-26 | 103 | 0d | Project Manager 1; Wireless Network Admin 1 | 80h | 3,874 |
| 105 | 1.7.8.6 | Complete monitoring and controlling phase review | 7d | 2015-08-27 | 2015-09-04 | 104 | 0d | Training Manager; System Test Analyst 1; System Test Analyst 2 | 168h | 5,261.2 |
| 106 | 1.8 | **Acceptance** | 14d | 2015-09-07 | 2015-09-24 |  | 0d |  | 216h | 11,147.68 |
| 107 | 1.8.1 | Review and approve deliverables | 4d | 2015-09-07 | 2015-09-10 | 105 | 0d | Project Manager 1 | 32h | 1,664 |
| 108 | 1.8.2 | Prepare acceptance testing/checklist | 3d | 2015-09-11 | 2015-09-15 | 107 | 0d | Technical Writer; Technical Writer 2 | 48h | 1,868.16 |
| 109 | 1.8.3 | Conduct acceptance testing | 1d | 2015-09-16 | 2015-09-16 | 108 | 0d | Project Manager 1; System Test Analyst 1; System Test Analyst 2 | 24h | 944.8 |
| 110 | 1.8.4 | Complete revisions from acceptance testing/checklist | 2d | 2015-09-17 | 2015-09-18 | 109 | 0d | General Manager; Project Manager 1; Technical Writer 2 | 48h | 3,070.72 |
| 111 | 1.8.5 | **Acceptance document/certificate** | 4d | 2015-09-21 | 2015-09-24 |  | 0d |  | 64h | 3,600 |
| 112 | 1.8.5.1 | Obtain validation of customer's satisfaction | 1d | 2015-09-21 | 2015-09-21 | 110 | 0d | General Manager; Project Manager 1 | 16h | 1,224 |
| 113 | 1.8.5.2 | Obtain customer signature/approval | 3d | 2015-09-22 | 2015-09-24 | 112 | 0d | Project Manager 1; Project Manager 2 | 48h | 2,376 |
| 114 | 1.9 | **Finalize** | 2d | 2015-09-25 | 2015-09-28 |  | 0d |  | 24h | 1,992 |
| 115 | 1.9.1 | Collect all documents | 1d | 2015-09-25 | 2015-09-25 | 113 | 0d | General Manager | 8h | 808 |
| 116 | 1.9.2 | Sign off on all invoices | 1d | 2015-09-28 | 2015-09-28 | 115 | 0d | Project Manager 2; General Manager | 16h | 1,184 |
